# Сопроводительный файл

Schedule from MS Project, 2002-01-10 to 2002-04-17, status date 2002-02-10, costs in $, A marks actual dates.
MS Project 2002
Группировка задач по длительности.

## Calendars

- Standard: Mon-Fri 08:00-12:00, 13:00-17:00; Sat-Sun off.

## Resources

| Resource | Group | Rate |
| --- | --- | --- |
| Иванов | Редактор раздела | 0.25 |
| Петров | Редактор раздела | 0.25 |
| Сидоров | Редактор раздела | 0.25 |
| Уваров |  | 0.25 |
| Галкина |  | 0.25 |
| Ураганов |  | 0.25 |
| Васин |  | 0.25 |
| Козлов |  | 0.25 |
| Фотомодель по контракту |  | 0.25 |
| Жуков |  | 0.25 |
| Еремин |  | 0.25 |
| Сергеева |  | 0.25 |
| Улендеева |  | 0.25 |
| Баранов |  | 0.25 |
| Лимонов |  | 0.25 |
| Бурков |  | 0.25 |
| Семенов |  | 0.25 |
| Борисов |  | 0.25 |
| Тарарухин |  | 0.25 |
| Терехов |  | 0.25 |

## Schedule

| ID | WBS | Task | Type | Duration | Start | Finish | Predecessors | Complete | Remaining | Baseline start | Baseline finish | Baseline duration | Total slack | Free slack | Constraint | Resources | Work | Actual work | Cost | Baseline cost | Actual cost |
| --- | --- | --- | --- | --- | --- | --- | --- | --- | --- | --- | --- | --- | --- | --- | --- | --- | --- | --- | --- | --- | --- |
| 1 | PUBL | **Подготовка номера журнала к изданию** |  | 69.83d | 2002-01-10 A | 2002-04-17 |  | 22% | 54.2d | 2002-01-10 | 2002-04-01 | 58d | 0d |  |  |  | 1542.13h | 222.33h | 1,905.53 | 9,443.98 | 575.58 |
| 2 | PUBLAAA | **Планирование номера** |  | 13d | 2002-01-10 A | 2002-01-28 A |  | 100% |  | 2002-01-10 | 2002-01-25 | 12d |  |  |  |  | 105.93h | 105.93h | 46.48 | 620.04 | 46.48 |
| 3 | PUBLAAA-1 | Сбор предложений от авторов |  | 5d | 2002-01-10 A | 2002-01-16 A |  | 100% |  | 2002-01-10 | 2002-01-16 | 5d |  |  | start no earlier than 2002-01-07 | Иванов [20%]; Петров [25%]; Сидоров [20%] | 26h | 26h | 26.5 | 180 | 26.5 |
| 4 | PUBLAAA-2 | Подготовка плана номера |  | 3d | 2002-01-17 A | 2002-01-21 A | 3 | 100% |  | 2002-01-17 | 2002-01-21 | 3d |  |  |  | Иванов [20%]; Петров [20.8%]; Сидоров [20%]; Уваров [12.5%] | 17.6h | 17.6h | 4.4 | 126 | 4.4 |
| 5 | PUBLAAA-3 | Предварительная редколлегия |  | 1d | 2002-01-22 A | 2002-01-22 A | 4 | 100% |  | 2002-01-22 | 2002-01-22 | 1d |  |  |  | Иванов [50%]; Петров [27.1%]; Сидоров [27.1%]; Галкина [50%]; Уваров [62.5%] | 17.33h | 17.33h | 4.33 | 109.02 | 4.33 |
| 6 | PUBLAAA-4 | Доработка планов с учетом замечаний |  | 3d | 2002-01-23 A | 2002-01-25 A | 5 | 100% |  | 2002-01-23 | 2002-01-24 | 2d |  |  |  | Иванов [43.8%]; Петров [31.2%]; Сидоров [37.5%] | 27h | 27h | 6.75 | 96 | 6.75 |
| 7 | PUBLAAA-5 | Редколлегия |  | 1d | 2002-01-28 A | 2002-01-28 A | 6 | 100% |  | 2002-01-25 | 2002-01-25 | 1d |  |  |  | Иванов [50%]; Петров [37.5%]; Сидоров [37.5%]; Галкина [50%]; Уваров [50%] | 18h | 18h | 4.5 | 109.02 | 4.5 |
| 8 | PUBLAAA-6 | План номера утвержден | milestone | 0d | 2002-01-28 A | 2002-01-28 A | 7 | 100% |  | 2002-01-25 | 2002-01-25 | 0d |  |  |  |  |  |  |  |  |  |
| 9 | PUBLAAB | **Подготовка текстов** |  | 34.33d | 2002-01-29 A | 2002-03-18 |  | 23% | 26.59d | 2002-01-28 | 2002-03-13 | 33d | 19.5d |  |  |  | 627.2h | 92.4h | 1,156.8 | 4,358.5 | 23.1 |
| 10 | PUBLAAB-1 | Подготовка редакционных заданий |  | 3d | 2002-01-29 A | 2002-01-31 A | 8 | 100% |  | 2002-01-28 | 2002-01-30 | 3d |  |  |  | Иванов [50%]; Петров [58.3%]; Сидоров [50%]; Галкина [33.3%] | 46h | 46h | 11.5 | 262.5 | 11.5 |
| 11 | PUBLAAB-2 | Рассылка заданий авторам |  | 2d | 2002-02-01 A | 2002-02-04 A | 10 | 100% |  | 2002-01-31 | 2002-01-31 | 1d |  |  |  | Галкина [150%] | 24h | 24h | 6 | 25 | 6 |
| 12 | PUBLAAB-3 | Утверждение заданий |  | 3.33d | 2002-02-05 A | 2002-02-08 A | 11 | 100% |  | 2002-02-01 | 2002-02-05 | 3d |  |  |  | Иванов [30%]; Петров [30%]; Сидоров [30%]; Ураганов [30%] | 22.4h | 22.4h | 5.6 | 144 | 5.6 |
| 13 | PUBLAAB-4 | Статьи в работе у авторов | milestone | 0d | 2002-02-08 A | 2002-02-08 A | 12 | 100% |  | 2002-02-05 | 2002-02-05 | 0d |  |  |  |  |  |  |  |  |  |
| 14 | PUBLAAB-5 | Статьи поступили в редакцию | milestone | 0d | 2002-02-22 | 2002-02-22 | 13FS+10d |  |  | 2002-02-19 | 2002-02-19 | 0d | 0d |  |  |  |  |  | 1,000 | 1,000 |  |
| 15 | PUBLAAB-6 | Редактирование материалов |  | 14.62d | 2002-02-22 | 2002-03-14 | 14 |  |  | 2002-02-20 | 2002-03-05 | 10d | 0d |  |  | Иванов [46.1%]; Петров [46.1%]; Сидоров [46.1%] | 154h |  | 38.5 | 960 |  |
| 16 | PUBLAAB-7 | Техническое редактирование |  | 14d | 2002-02-26 | 2002-03-18 | 15SS+2d |  |  | 2002-02-22 | 2002-03-13 | 14d | 0d |  |  | Васин; Козлов; Галкина [50%]; Иванов [30%]; Петров [30%]; Сидоров [30%] | 380.8h |  | 95.2 | 1,967 |  |
| 17 | PUBLAAB-8 | Подготовка текстов завершена | milestone | 0d | 2002-03-18 | 2002-03-18 | 16 |  |  | 2002-03-13 | 2002-03-13 | 0d | 19.5d | 0d |  |  |  |  |  |  |  |
| 18 | PUBLAAC | **Верстка журнала** |  | 44.96d | 2002-01-29 A | 2002-04-01 |  | 16% | 37.86d | 2002-01-28 | 2002-03-22 | 40d | 11.88d |  |  |  | 579.2h | 24h | 644.8 | 3,613.5 | 506 |
| 19 | PUBLAAC-1 | **Подготовка обложки** |  | 37.33d | 2002-01-29 A | 2002-03-21 | 8 | 60% | 14.93d | 2002-01-28 | 2002-03-18 | 36d | 19.5d |  |  |  | 59.2h | 24h | 514.8 | 1,430.5 | 506 |
| 20 | PUBLAAC-1.1 | Кастинг для выбора фотомодели |  | 5d | 2002-01-29 A | 2002-02-04 A |  | 100% |  | 2002-01-28 | 2002-02-01 | 5d |  |  |  |  |  |  | 500 | 500 | 500 |
| 21 | PUBLAAC-1.2 | Фотосъемка модели |  | 4d | 2002-02-05 A | 2002-02-08 A | 20 | 100% |  | 2002-02-04 | 2002-02-06 | 3d |  |  |  | Фотомодель по контракту [37.5%]; Жуков [37.5%] | 24h | 24h | 6 | 687.5 | 6 |
| 22 | PUBLAAC-1.3 | Подготовка макета обложки |  | 3d | 2002-02-11 | 2002-02-13 | 21 |  |  | 2002-02-07 | 2002-02-11 | 3d | 41.83d | 22.33d |  | Еремин [70%]; Жуков [20%] | 21.6h |  | 5.4 | 141 |  |
| 23 | PUBLAAC-1.4 | Подготовка анонсов материалов номера для обложки |  | 3d | 2002-03-18 | 2002-03-21 | 17, 22 |  |  | 2002-03-14 | 2002-03-18 | 3d | 19.5d | 0d |  | Сидоров [70%] | 13.6h |  | 3.4 | 102 |  |
| 24 | PUBLAAC-1.5 | Обложка готова | milestone | 0d | 2002-03-21 | 2002-03-21 | 23 |  |  | 2002-03-18 | 2002-03-18 | 0d | 19.5d |  |  |  |  |  |  |  |  |
| 25 | PUBLAAC-2 | Обработка текста и иллюстраций |  | 14d | 2002-03-01 | 2002-03-21 | 16SS+3d |  |  | 2002-02-27 | 2002-03-18 | 14d | 0d |  |  | Сергеева; Улендеева | 224h |  | 56 | 945 |  |
| 26 | PUBLAAC-3 | Вычитка |  | 14d | 2002-03-06 | 2002-03-26 | 25SS+3d |  |  | 2002-03-04 | 2002-03-21 | 14d | 13.88d | 0d |  | Баранов [50%]; Ураганов [50%] | 112h |  | 28 | 350 |  |
| 27 | PUBLAAC-4 | Сверка |  | 12d | 2002-03-14 | 2002-04-01 | 26SS+3d |  |  | 2002-03-07 | 2002-03-22 | 12d | 11.88d |  |  | Баранов [50%]; Ураганов [50%]; Иванов [30%]; Петров [30%]; Сидоров [30%] | 182.4h |  | 45.6 | 876 |  |
| 28 | PUBLAAC-5 | Подготовка оглавления |  | 2d | 2002-03-21 | 2002-03-25 | 25 |  |  | 2002-03-19 | 2002-03-20 | 2d | 0d |  |  | Сидоров [10%] | 1.6h |  | 0.4 | 12 |  |
| 29 | PUBLAAC-6 | Номер сверстан | milestone | 0d | 2002-03-25 | 2002-03-25 | 28 |  |  | 2002-03-20 | 2002-03-20 | 0d | 0d |  |  |  |  |  |  |  |  |

| ID | WBS | Task | Type | Duration | Start | Finish | Predecessors | Baseline start | Baseline finish | Baseline duration | Total slack | Resources | Work | Cost | Baseline cost |
| --- | --- | --- | --- | --- | --- | --- | --- | --- | --- | --- | --- | --- | --- | --- | --- |
| 30 | PUBLAAD | **Предпечатная подготовка** |  | 17.5d | 2002-03-25 | 2002-04-17 |  | 2002-03-20 | 2002-04-01 | 8d | 0d |  | 229.8h | 57.45 | 851.93 |
| 31 | PUBLAAD-1 | Конвертция сверстанного номера в формат Mac |  | 7.5d | 2002-03-25 | 2002-04-03 | 29 | 2002-03-20 | 2002-03-25 | 3d | 0d | Лимонов [25%]; Бурков [25%]; Семенов [25%] | 45h | 11.25 | 192.18 |
| 32 | PUBLAAD-2 | Цветоделение |  | 7d | 2002-04-03 | 2002-04-12 | 31 | 2002-03-25 | 2002-03-29 | 7d | 0d | Борисов [25%]; Тарарухин [25%]; Терехов [25%]; Бурков [20%]; Семенов [20%] | 64.4h | 16.1 | 214.37 |
| 33 | PUBLAAD-3 | Коррекция |  | 7d | 2002-04-04 | 2002-04-15 | 32SS+1d | 2002-03-26 | 2002-03-30 | 7d | 0d | Лимонов [25%]; Бурков [25%]; Семенов [25%] | 42h | 10.5 | 179.37 |
| 34 | PUBLAAD-4 | Вывод пленок |  | 7d | 2002-04-08 | 2002-04-17 | 33SS+2d | 2002-03-28 | 2002-04-01 | 7d | 0d | Лимонов [25%]; Бурков [25%]; Борисов [30%]; Тарарухин [30%]; Терехов [30%] | 78.4h | 19.6 | 266 |
| 35 | PUBLAAD-5 | Номер готов к передаче в типографию | milestone | 0d | 2002-04-17 | 2002-04-17 | 34 | 2002-04-01 | 2002-04-01 | 0d | 0d |  |  |  |  |
